# Statybos darbų atlikimo grafikas

Schedule from MS Project, 2020-09-28 to 2024-03-19, costs in €.

## Calendars

- Standard: Mon-Fri 08:00-12:00, 13:00-17:00; Sat-Sun off. Exceptions (off unless hours are given): 2013-01-01 to 2030-01-01 (Naujieji metai, recurring), 2013-02-16 to 2030-02-16 (Valstybės atkurimo diena, recurring), 2013-03-11 to 2030-03-11 (Nepriklausomybes atkurimo diena, recurring), 2013-05-01 to 2030-05-01 (Tarptautine darbininku diena, recurring), 2013-06-24 to 2030-06-24 (Jonines (Rasos), recurring), 2013-07-06 to 2030-07-06 (Valstybes (Lietuvos karaliaus Mindaugo karunavimo) diena, recurring), 2013-08-15 to 2030-08-15 (Zoline, Sv. Mergeles Marijos dangun emimo svente, recurring), 2013-11-01 to 2030-11-01 (Visu sventuju diena, recurring), 2013-12-24 to 2030-12-24 (Sv. Kucios, recurring), 2013-12-25 to 2030-12-25 (Sv. Kaledos, recurring), 2013-12-26 to 2030-12-26 (Sv. Kaledos (antroji diena), recurring), 2019-06-20 to 2024-04-02 07:30-11:30, 12:15-16:30 (Darbo diena (I-IV) 07:30-16:30, recurring), 2019-06-21 to 2030-12-27 07:30-11:30, 12:15-15:15 (Darbo diena (V) 07:30-15:15, recurring), 2021-04-05 (Sv. Velykos (antroji diena)), 2022-04-18 (Sv. Velykos (antroji diena)), 2023-04-10 (Sv. Velykos (antroji diena)).

## Resources

| Resource | Rate |
| --- | --- |
| Rangovas |  |
| Litgrid AB |  |
| Ekspertizės rangovas |  |
| Infostatyba |  |
| PV |  |
| ESO |  |
| _ITTAD ITTC TIG vyresnysis inžinierius | 17.8 |
| _ITTAD ITTC DPG PVS administratorius | 17.8 |
| _ITTAD ITTC VSG DVS administratorius | 17.8 |
| _ITTAD ITTC DPG duomenų tinklo administratorius (KR) | 17.8 |
| _ITTAD ITTC DPG duomenų tinklo administratorius (IP) | 17.8 |
| _Rangovas |  |
| _ITTAD ITTC TIG grupės vadovas |  |
| _VAD FSS apsaugos sistemų specialistas |  |
| _ITTAD ITTC DPG grupės vadovas |  |
| _ITTAD ITTC TIG technologinio tinklo vyresnysis inžinierius |  |
| _ITTAD ITTC VSG grupės vadovas |  |
| _PTD DSAS darbuotojų saugos ir sveikatos vyresnysis inžinierius |  |
| _PTD DSAS aplinkosaugos vyresnysis inžinierius |  |
| _PTD RAAS skyriaus vadovas |  |
| _SVD SPS STRG RAA vadovaujantis inžinierius |  |
| _SVD SPS režimų planavimo grupės vadovas |  |
| _SVD SPS STRG inžinierius |  |
| _SVD SVC TVG ekspertas |  |
| _SVD SPS režimų planavimo grupės vadovaujantis inžinierius |  |
| _SVD SVC TVG analitikas |  |
| _PTD IPC Statybų priežiūros proceso vadovas |  |
| _ISPS kibernetinės saugos specialistas |  |
| _SD STS vadovaujantis inžinierius |  |
| _SVD ROPS RPPAG elektros apskaitų vadovaujantis inžinierius |  |
| _PTD TCHS linijų vyresnysis inžinierius |  |
| _PTD TCHS PPĮG pastočių vyresnysis inžinierius |  |
| _PTD TCHS RAA įrenginių grupės RAA vyresnysis inžinierius |  |
| _KS komunikacijos projektų vadovas |  |

## Schedule

| ID | WBS | Task | Type | Duration | Start | Finish | Predecessors | Baseline start | Baseline finish | Baseline duration | Total slack | Resources | Work | Cost |
| --- | --- | --- | --- | --- | --- | --- | --- | --- | --- | --- | --- | --- | --- | --- |
| 1 | 1 | S3 - Pasirašyta sutartis | milestone | 0d | 2020-09-28 | 2020-09-28 |  |  |  |  | 0d | Rangovas; Litgrid AB |  |  |
| 2 | 2 | Prašymas pateikti reikalingą dokumentaciją/informaciją projektavimo darbams |  | 5d | 2020-09-28 | 2020-10-05 | 1 |  |  |  | 0d | Rangovas | 40h |  |
| 3 | 3 | Pateikta reikalinga dokumentacija/informacija projektavimo darbams |  | 15d | 2020-10-05 | 2020-10-26 | 2 | 2019-12-18 | 2020-01-27 | 25d | 0d | Litgrid AB | 120h |  |
| 4 | 4 | **I ETAPAS. PROJEKTAVIMAS** |  | 309d | 2020-10-05 | 2021-12-22 |  | 2019-12-18 | 2020-08-18 | 166d | 15d |  | 7535.44h | 43,606.25 |
| 5 | 4.1 | **Projektiniai pasiūlymai** |  | 309d | 2020-10-05 | 2021-12-22 |  |  |  |  | 15d |  | 7535.44h | 43,606.25 |
| 6 | 4.1.1 | **Tiekėjo darbų atlikimo grafikas** |  | 56d | 2020-10-26 | 2021-01-14 |  |  |  |  | 0d |  | 0.13h |  |
| 7 | 4.1.1.1 | **Darbų atlikimo grafikas** |  | 56d | 2020-10-26 | 2021-01-14 |  |  |  |  | 0d |  | 0.13h |  |
| 8 | 4.1.1.1.1 | Parengti darbų atlikimo grafiką |  | 1d | 2020-10-26 | 2020-10-27 | 3 |  |  |  | 0d |  |  |  |
| 9 | 4.1.1.1.2 | Pateikti 1 peržiūrai darbų atlikimo grafiką |  | 21d | 2020-10-27 | 2020-11-24 | 8 |  |  |  | 0d | _Rangovas [0.1%] | 0.1h |  |
| 10 | 4.1.1.1.3 | Pateikti pastabas po 1 peržiūros |  | 10d | 2020-11-25 | 2020-12-08 | 9 |  |  |  | 0d |  |  |  |
| 11 | 4.1.1.1.4 | Pateikti 2 peržiūrai darbų atlikimo grafiką |  | 7d | 2020-12-09 | 2020-12-17 | 10 |  |  |  | 0d | _Rangovas [0.1%] | 0.03h |  |
| 12 | 4.1.1.1.5 | Pateikti pastabas po 2 peržiūros |  | 5d | 2020-12-17 | 2020-12-28 | 11 |  |  |  | 0d |  |  |  |
| 13 | 4.1.1.1.6 | Pateikti 3 peržiūrai darbų atlikimo grafiką |  | 7d | 2020-12-28 | 2021-01-07 | 12 |  |  |  | 0d |  |  |  |
| 14 | 4.1.1.1.7 | Pateikti pastabas po 3 peržiūros |  | 5d | 2021-01-07 | 2021-01-14 | 13 |  |  |  | 0d |  |  |  |
| 15 | 4.1.1.1.8 | Darbų atlikimo grafikas suderintas | milestone | 0d | 2021-01-14 | 2021-01-14 | 14 |  |  |  | 0d |  |  |  |
| 16 | 4.1.2 | **I ETAPAS. PROJEKTAVIMAS** |  | 186d | 2020-10-05 | 2021-06-30 |  |  |  |  | 71d |  | 4711.22h | 30,434.19 |
| 17 | 4.1.2.1 | Projektuotojo pateiktas atsakingų asmenų paskyrimas |  | 15d | 2021-01-14 | 2021-02-04 | 15 |  |  |  | 787d |  |  |  |
| 18 | 4.1.2.2 | Prašymas pateikti reikalingą dokumentaciją/informaciją techniniems darbams |  | 5d | 2021-01-14 | 2021-01-21 | 15 |  |  |  | 0d | _Rangovas [0.1%] | 0.02h |  |
| 19 | 4.1.2.3 | Pateikta reikalinga dokumentacija/informacija techniniems darbams |  | 10d | 2021-01-21 | 2021-02-04 | 18 |  |  |  | 0d | _ITTAD ITTC TIG grupės vadovas; _VAD FSS apsaugos sistemų specialistas; _ITTAD ITTC DPG duomenų tinklo administratorius (IP); _ITTAD ITTC DPG duomenų tinklo administratorius (KR); _ITTAD ITTC DPG PVS administratorius; _ITTAD ITTC DPG grupės vadovas; _ITTAD ITTC TIG technologinio tinklo vyresnysis inžinierius; _ITTAD ITTC TIG vyresnysis inžinierius; _ITTAD ITTC VSG DVS administratorius; _ITTAD ITTC VSG grupės vadovas; _PTD DSAS darbuotojų saugos ir sveikatos vyresnysis inžinierius; _PTD DSAS aplinkosaugos vyresnysis inžinierius; _PTD RAAS skyriaus vadovas; _SVD SPS STRG RAA vadovaujantis inžinierius; _SVD SPS režimų planavimo grupės vadovas; _SVD SPS STRG inžinierius; _SVD SVC TVG ekspertas; _SVD SPS režimų planavimo grupės vadovaujantis inžinierius; _SVD SVC TVG analitikas; _PTD IPC Statybų priežiūros proceso vadovas; _ISPS kibernetinės saugos specialistas; _SD STS vadovaujantis inžinierius; _SVD ROPS RPPAG elektros apskaitų vadovaujantis inžinierius | 751h | 5,838.4 |
| 20 | 4.1.2.4 | Specialiųjų prisijungimo sąlygų ir specialiųjų reikalavimų ir visų reikalingų suderinimų, leidimų gavimas |  | 5d | 2021-02-04 | 2021-02-11 | 19 |  |  |  | 0d |  |  |  |
| 21 | 4.1.2.5 | Sutikimų iš atsakingų institucijų ir asmenų gavimas |  | 5d | 2021-02-04 | 2021-02-11 | 19 |  |  |  | 0d |  |  |  |
| 22 | 4.1.2.6 | Konsultacijos rengimo metu |  | 25d | 2020-10-05 | 2020-11-09 | 2 |  |  |  | 848d | _ITTAD ITTC TIG grupės vadovas; _VAD FSS apsaugos sistemų specialistas; _ITTAD ITTC DPG duomenų tinklo administratorius (IP); _ITTAD ITTC DPG duomenų tinklo administratorius (KR); _ITTAD ITTC DPG PVS administratorius; _ITTAD ITTC DPG grupės vadovas; _ITTAD ITTC TIG technologinio tinklo vyresnysis inžinierius; _ITTAD ITTC TIG vyresnysis inžinierius; _ITTAD ITTC VSG DVS administratorius; _ITTAD ITTC VSG grupės vadovas; _PTD DSAS darbuotojų saugos ir sveikatos vyresnysis inžinierius; _PTD DSAS aplinkosaugos vyresnysis inžinierius; _PTD RAAS skyriaus vadovas; _PTD TCHS linijų vyresnysis inžinierius; _PTD TCHS PPĮG pastočių vyresnysis inžinierius; _PTD TCHS RAA įrenginių grupės RAA vyresnysis inžinierius; _SVD SPS STRG RAA vadovaujantis inžinierius; _SVD SPS režimų planavimo grupės vadovas; _SVD SPS STRG inžinierius; _SVD SVC TVG ekspertas; _PTD IPC Statybų priežiūros proceso vadovas; _SVD SPS režimų planavimo grupės vadovaujantis inžinierius; _SVD SVC TVG analitikas; _ISPS kibernetinės saugos specialistas; _SD STS vadovaujantis inžinierius; _SVD ROPS RPPAG elektros apskaitų vadovaujantis inžinierius | 1639h | 11,423.74 |
| 23 | 4.1.2.7 | Pateikti geologinių tyrinėjimų vietas susiderinimui |  | 5d | 2020-10-05 | 2020-10-12 | 2 |  |  |  | 868d | _Rangovas [0.1%] | 0.02h |  |
| 24 | 4.1.2.8 | Atlikti inžineriniai geodeziniai tyrinėjimai ir pateika įregistravimo pažyma |  | 20d | 2021-02-11 | 2021-03-15 | 19, 20, 21 |  |  |  | 0d | _Rangovas [0.1%] | 0.1h |  |

Notes:
- 4: jeigu perkame iki rakto - paliekame. / Jeigu perkame atskirai - padaryti inactive ar i�trinti
- 22: Pagal poreikį konsultacijos daromos

| ID | WBS | Task | Type | Duration | Start | Finish | Predecessors | Total slack | Resources | Work | Cost |
| --- | --- | --- | --- | --- | --- | --- | --- | --- | --- | --- | --- |
| 25 | 4.1.2.9 | **Projektiniai pasiūlymai** |  | 75d | 2021-03-15 | 2021-06-30 |  | 0d |  | 2321.08h | 13,172.05 |
| 26 | 4.1.2.9.1 | Projektinių pasiūlymų projekto rengimas |  | 30d | 2021-03-15 | 2021-04-27 | 24 | 0d | _Rangovas [0.1%] | 0h |  |
| 27 | 4.1.2.9.2 | Pakoreguoti ir pateikti projektinių pasiūlymų projektą 1 peržiūrai | milestone | 0d | 2021-04-27 | 2021-04-27 | 26 | 0d |  |  |  |
| 28 | 4.1.2.9.3 | Pateikti pastabas po 1 projektinių pasiūlymų projekto peržiūros |  | 10d | 2021-04-27 | 2021-05-11 | 27 | 0d | _VAD FSS apsaugos sistemų specialistas; _ITTAD ITTC DPG duomenų tinklo administratorius (IP); _ITTAD ITTC DPG duomenų tinklo administratorius (KR); _ITTAD ITTC DPG PVS administratorius; _ITTAD ITTC DPG grupės vadovas; _ITTAD ITTC TIG technologinio tinklo vyresnysis inžinierius; _ITTAD ITTC TIG grupės vadovas; _ITTAD ITTC TIG vyresnysis inžinierius; _ITTAD ITTC VSG DVS administratorius; _ITTAD ITTC VSG grupės vadovas; _PTD DSAS darbuotojų saugos ir sveikatos vyresnysis inžinierius; _PTD DSAS aplinkosaugos vyresnysis inžinierius; _PTD RAAS skyriaus vadovas; _PTD TCHS linijų vyresnysis inžinierius; _PTD TCHS PPĮG pastočių vyresnysis inžinierius; _PTD TCHS RAA įrenginių grupės RAA vyresnysis inžinierius; _SVD SPS STRG RAA vadovaujantis inžinierius; _SVD SPS režimų planavimo grupės vadovas; _SVD SPS STRG inžinierius; _SVD SVC TVG ekspertas; _SVD SPS režimų planavimo grupės vadovaujantis inžinierius; _PTD IPC Statybų priežiūros proceso vadovas; _SVD SVC TVG analitikas; _ISPS kibernetinės saugos specialistas; _SD STS vadovaujantis inžinierius; _SVD ROPS RPPAG elektros apskaitų vadovaujantis inžinierius | 1161h | 5,718.73 |
| 29 | 4.1.2.9.4 | Pakoreguoti ir pateikti projektinių pasiūlymų projektą 2 peržiūrai |  | 10d | 2021-05-11 | 2021-05-25 | 28 | 0d | _Rangovas [0.1%] | 0.05h |  |
| 30 | 4.1.2.9.5 | Pateikti pastabas po 2 projektinių pasiūlymų projekto peržiūros |  | 10d | 2021-05-25 | 2021-06-08 | 29 | 0d | _VAD FSS apsaugos sistemų specialistas; _ITTAD ITTC DPG duomenų tinklo administratorius (IP); _ITTAD ITTC DPG duomenų tinklo administratorius (KR); _ITTAD ITTC DPG PVS administratorius; _ITTAD ITTC DPG grupės vadovas; _ITTAD ITTC TIG technologinio tinklo vyresnysis inžinierius; _ITTAD ITTC TIG grupės vadovas; _ITTAD ITTC TIG vyresnysis inžinierius; _ITTAD ITTC VSG DVS administratorius; _ITTAD ITTC VSG grupės vadovas; _PTD DSAS darbuotojų saugos ir sveikatos vyresnysis inžinierius; _PTD DSAS aplinkosaugos vyresnysis inžinierius; _PTD RAAS skyriaus vadovas; _PTD TCHS linijų vyresnysis inžinierius; _PTD TCHS PPĮG pastočių vyresnysis inžinierius; _PTD TCHS RAA įrenginių grupės RAA vyresnysis inžinierius; _SVD SPS STRG RAA vadovaujantis inžinierius; _SVD SPS režimų planavimo grupės vadovas; _SVD SPS STRG inžinierius; _SVD SVC TVG ekspertas; _SVD SPS režimų planavimo grupės vadovaujantis inžinierius; _SVD SVC TVG analitikas; _ISPS kibernetinės saugos specialistas; _PTD IPC Statybų priežiūros proceso vadovas; _SD STS vadovaujantis inžinierius; _SVD ROPS RPPAG elektros apskaitų vadovaujantis inžinierius | 726h | 4,580.91 |
| 31 | 4.1.2.9.6 | Pakoreguoti ir pateikti projektinių pasiūlymų projektą 3 peržiūrai |  | 5d | 2021-06-08 | 2021-06-15 | 30 | 0d | _Rangovas [0.1%] | 0.02h |  |
| 32 | 4.1.2.9.7 | Pateikti pastabas/suderinti po 3 projektinių pasiūlymų projekto |  | 10d | 2021-06-15 | 2021-06-30 | 31 | 0d | _VAD FSS apsaugos sistemų specialistas; _ITTAD ITTC DPG duomenų tinklo administratorius (IP); _ITTAD ITTC DPG duomenų tinklo administratorius (KR); _ITTAD ITTC DPG PVS administratorius; _ITTAD ITTC DPG grupės vadovas; _ITTAD ITTC TIG technologinio tinklo vyresnysis inžinierius; _ITTAD ITTC TIG grupės vadovas; _ITTAD ITTC TIG vyresnysis inžinierius; _ITTAD ITTC VSG DVS administratorius; _ITTAD ITTC VSG grupės vadovas; _PTD DSAS darbuotojų saugos ir sveikatos vyresnysis inžinierius; _PTD DSAS aplinkosaugos vyresnysis inžinierius; _PTD RAAS skyriaus vadovas; _PTD TCHS linijų vyresnysis inžinierius; _PTD TCHS PPĮG pastočių vyresnysis inžinierius; _PTD TCHS RAA įrenginių grupės RAA vyresnysis inžinierius; _SVD SPS STRG RAA vadovaujantis inžinierius; _SVD SPS režimų planavimo grupės vadovas; _SVD SPS STRG inžinierius; _SVD SVC TVG ekspertas; _SVD SPS režimų planavimo grupės vadovaujantis inžinierius; _PTD IPC Statybų priežiūros proceso vadovas; _SVD SVC TVG analitikas; _ISPS kibernetinės saugos specialistas; _SD STS vadovaujantis inžinierius; _SVD ROPS RPPAG elektros apskaitų vadovaujantis inžinierius | 434h | 2,872.42 |
| 33 | 4.1.2.9.8 | Projektiniai pasiūlymai suderinti | milestone | 0d | 2021-06-30 | 2021-06-30 | 32 | 0d |  |  |  |
| 34 | 4.1.2.9.9 | Projektiniai pasiūlymai patvirtinti | milestone | 0d | 2021-06-30 | 2021-06-30 | 33 | 0d |  |  |  |
| 35 | 4.1.3 | **Statybos leidimas** |  | 133d | 2021-06-15 | 2021-12-22 |  | 10d |  | 2824.08h | 13,172.05 |
| 36 | 4.1.3.1 | Komunikacija - Projektinių pasiūlymų viešinimo procedūros |  | 3d | 2021-06-15 | 2021-06-18 | 37SS-10d | 694d | _KS komunikacijos projektų vadovas | 4h |  |
| 37 | 4.1.3.2 | Projektas pateiktas į Infostatybą su visais reikiamais dokumentais |  | 1d | 2021-06-30 | 2021-07-01 | 33, 34 | 0d | _Rangovas [0.1%] | 0h |  |
| 38 | 4.1.3.3 | Pranešimas IS Infostatyba apie statybos pradžią, rangovo ir pagrindinių statybos sričių vadovų pasamdymą ar paskyrimą |  | 15d | 2021-07-01 | 2021-07-23 | 37 | 671d | _Rangovas | 120h |  |
| 39 | 4.1.3.4 | Patikrinta pateiktos dokumentacijos sudėtis |  | 3d | 2021-07-01 | 2021-07-07 | 37 | 0d | Infostatyba | 24h |  |
| 40 | 4.1.3.5 | Suinteresuotos organizacijos patikrino pateiktą dokumentaciją |  | 20d | 2021-07-07 | 2021-08-04 | 39 | 0d | Infostatyba | 160h |  |
| 41 | 4.1.3.6 | Išduotas statybos leidimas |  | 3d | 2021-08-04 | 2021-08-09 | 40 | 0d | Infostatyba | 24h |  |
| 42 | 4.1.3.7 | S4 - Statybos leidimas gautas | milestone | 0d | 2021-08-09 | 2021-08-09 | 41 | 0d |  |  |  |
| 43 | 4.1.3.8 | Komunikacija (SLD gavimas) |  | 4d | 2021-08-09 | 2021-08-13 | 42SS | 656d | _KS komunikacijos projektų vadovas | 3h |  |
| 44 | 4.1.3.9 | **Techninis darbo projektas suderintas/patvirtintas** |  | 96d | 2021-08-09 | 2021-12-22 |  | 0d |  | 2489.08h | 13,172.05 |
| 45 | 4.1.3.9.1 | **Techninis darbo projektas** |  | 96d | 2021-08-09 | 2021-12-22 |  | 0d |  | 2489.08h | 13,172.05 |
| 46 | 4.1.3.9.1.1 | Techninio darbo projekto rengimas |  | 30d | 2021-08-09 | 2021-09-20 | 42 | 0d | _Rangovas [0.1%] | 0h |  |
| 47 | 4.1.3.9.1.2 | Pakoreguoti ir pateikti techninį darbo projektą 1 peržiūrai | milestone | 0d | 2021-09-20 | 2021-09-20 | 46 | 0d |  |  |  |
| 48 | 4.1.3.9.1.3 | Pateikti pastabas po 1 techninio darbo projekto peržiūros |  | 10d | 2021-09-20 | 2021-10-04 | 47 | 0d | _VAD FSS apsaugos sistemų specialistas; _ITTAD ITTC DPG duomenų tinklo administratorius (IP); _ITTAD ITTC DPG duomenų tinklo administratorius (KR); _ITTAD ITTC DPG PVS administratorius; _ITTAD ITTC DPG grupės vadovas; _ITTAD ITTC TIG technologinio tinklo vyresnysis inžinierius; _ITTAD ITTC TIG grupės vadovas; _ITTAD ITTC TIG vyresnysis inžinierius; _ITTAD ITTC VSG DVS administratorius; _ITTAD ITTC VSG grupės vadovas; _PTD DSAS darbuotojų saugos ir sveikatos vyresnysis inžinierius; _PTD DSAS aplinkosaugos vyresnysis inžinierius; _PTD RAAS skyriaus vadovas; _PTD TCHS linijų vyresnysis inžinierius; _PTD TCHS PPĮG pastočių vyresnysis inžinierius; _PTD TCHS RAA įrenginių grupės RAA vyresnysis inžinierius; _SVD SPS STRG RAA vadovaujantis inžinierius; _SVD SPS režimų planavimo grupės vadovas; _SVD SPS STRG inžinierius; _SVD SVC TVG ekspertas; _SVD SPS režimų planavimo grupės vadovaujantis inžinierius; _PTD IPC Statybų priežiūros proceso vadovas; _SVD SVC TVG analitikas; _ISPS kibernetinės saugos specialistas; _SD STS vadovaujantis inžinierius; _SVD ROPS RPPAG elektros apskaitų vadovaujantis inžinierius | 1161h | 5,718.73 |
| 49 | 4.1.3.9.1.4 | Pakoreguoti ir pateikti techninį darbo projektą 2 peržiūrai |  | 10d | 2021-10-04 | 2021-10-18 | 48 | 0d | _Rangovas [0.1%] | 0.05h |  |
| 50 | 4.1.3.9.1.5 | Pateikti pastabas po 2 techninio darbo projekto peržiūros |  | 10d | 2021-10-18 | 2021-11-02 | 49 | 0d | _VAD FSS apsaugos sistemų specialistas; _ITTAD ITTC DPG duomenų tinklo administratorius (IP); _ITTAD ITTC DPG duomenų tinklo administratorius (KR); _ITTAD ITTC DPG PVS administratorius; _ITTAD ITTC DPG grupės vadovas; _ITTAD ITTC TIG technologinio tinklo vyresnysis inžinierius; _ITTAD ITTC TIG grupės vadovas; _ITTAD ITTC TIG vyresnysis inžinierius; _ITTAD ITTC VSG DVS administratorius; _ITTAD ITTC VSG grupės vadovas; _PTD DSAS darbuotojų saugos ir sveikatos vyresnysis inžinierius; _PTD DSAS aplinkosaugos vyresnysis inžinierius; _PTD RAAS skyriaus vadovas; _PTD TCHS linijų vyresnysis inžinierius; _PTD TCHS PPĮG pastočių vyresnysis inžinierius; _PTD TCHS RAA įrenginių grupės RAA vyresnysis inžinierius; _SVD SPS STRG RAA vadovaujantis inžinierius; _SVD SPS režimų planavimo grupės vadovas; _SVD SPS STRG inžinierius; _SVD SVC TVG ekspertas; _SVD SPS režimų planavimo grupės vadovaujantis inžinierius; _SVD SVC TVG analitikas; _ISPS kibernetinės saugos specialistas; _PTD IPC Statybų priežiūros proceso vadovas; _SD STS vadovaujantis inžinierius; _SVD ROPS RPPAG elektros apskaitų vadovaujantis inžinierius | 726h | 4,580.91 |
| 51 | 4.1.3.9.1.6 | Pakoreguoti ir pateikti techninį darbo projektą 3 peržiūrai |  | 5d | 2021-11-02 | 2021-11-09 | 50 | 0d | _Rangovas [0.1%] | 0.02h |  |
| 52 | 4.1.3.9.1.7 | Pateikti pastabas/suderinti po 3 techninio darbo projekto peržiūros |  | 10d | 2021-11-09 | 2021-11-23 | 51 | 0d | _VAD FSS apsaugos sistemų specialistas; _ITTAD ITTC DPG duomenų tinklo administratorius (IP); _ITTAD ITTC DPG duomenų tinklo administratorius (KR); _ITTAD ITTC DPG PVS administratorius; _ITTAD ITTC DPG grupės vadovas; _ITTAD ITTC TIG technologinio tinklo vyresnysis inžinierius; _ITTAD ITTC TIG grupės vadovas; _ITTAD ITTC TIG vyresnysis inžinierius; _ITTAD ITTC VSG DVS administratorius; _ITTAD ITTC VSG grupės vadovas; _PTD DSAS darbuotojų saugos ir sveikatos vyresnysis inžinierius; _PTD DSAS aplinkosaugos vyresnysis inžinierius; _PTD RAAS skyriaus vadovas; _PTD TCHS linijų vyresnysis inžinierius; _PTD TCHS PPĮG pastočių vyresnysis inžinierius; _PTD TCHS RAA įrenginių grupės RAA vyresnysis inžinierius; _SVD SPS STRG RAA vadovaujantis inžinierius; _SVD SPS režimų planavimo grupės vadovas; _SVD SPS STRG inžinierius; _SVD SVC TVG ekspertas; _SVD SPS režimų planavimo grupės vadovaujantis inžinierius; _PTD IPC Statybų priežiūros proceso vadovas; _SVD SVC TVG analitikas; _ISPS kibernetinės saugos specialistas; _SD STS vadovaujantis inžinierius; _SVD ROPS RPPAG elektros apskaitų vadovaujantis inžinierius | 434h | 2,872.42 |
| 53 | 4.1.3.9.1.8 | Techninis darbo projektas suderintas | milestone | 0d | 2021-11-23 | 2021-11-23 | 52 | 0d |  |  |  |

Notes:
- 34: kai taikoma
- 36: Jei reikalingas projektinių sprendinių pristatymas visuomenei (vie�inimo procedūros) pagal teisės aktus. Tikslas - vie�inti Litgrid tinklapyje apie projektinių sprendinių vie�inimo procedūr¹.

| ID | WBS | Task | Type | Duration | Start | Finish | Predecessors | Baseline start | Baseline finish | Baseline duration | Total slack | Free slack | Resources | Work | Cost |
| --- | --- | --- | --- | --- | --- | --- | --- | --- | --- | --- | --- | --- | --- | --- | --- |
| 54 | 4.1.3.9.1.9 | **Techninio darbo projekto bendroji ekspertizė** |  | 56d | 2021-10-04 | 2021-12-22 |  |  |  |  | 35d |  |  | 168h |  |
| 55 | 4.1.3.9.1.9.1 | Ekspertizės pirkimas |  | 5d | 2021-10-04 | 2021-10-11 | 48 |  |  |  | 615d |  |  |  |  |
| 56 | 4.1.3.9.1.9.2 | Techninio darbo projekto bendroji ekspertizė |  | 20d | 2021-11-23 | 2021-12-21 | 53 |  |  |  | 0d |  | Ekspertizės rangovas | 160h |  |
| 57 | 4.1.3.9.1.9.3 | Pateikta ekspertizės teigiama išvada projektui |  | 1d | 2021-12-21 | 2021-12-22 | 56 |  |  |  | 0d |  | Ekspertizės rangovas | 8h |  |
| 58 | 4.1.3.9.1.9.4 | S5 - Gautas teigiamas techninio darbo projekto - TDP ekspertizės aktas | milestone | 0d | 2021-12-22 | 2021-12-22 | 59 |  |  |  | 0d |  |  |  |  |
| 59 | 4.1.3.9.1.9.5 | Patvirtintas statinio projektas statytojo tvarkomuoju dokumentu, nurodant pagrindinius statinio techninius ir ekonominius duomenis, aplinkos ir kraštovaizdžio reikalavimus | milestone | 0d | 2021-12-22 | 2021-12-22 | 57 |  |  |  | 0d |  |  |  |  |
| 60 | 5 | **II ETAPAS. RANGOS DARBAI** |  | 827d | 2020-09-28 | 2024-01-04 |  | 2020-05-19 | 2022-01-18 | 424d | 51d |  |  | 12640h | 5,411.2 |
| 61 | 5.1 | Rangovo pateiktas atsakingų asmenų paskyrimas |  | 3d | 2021-12-22 | 2021-12-28 | 58 |  |  |  | 561d |  |  |  |  |
| 62 | 5.2 | Darbams atlikti reikalingos dokumentacijos pateikimas Rangovui |  | 3d | 2021-12-22 | 2021-12-28 | 58 |  |  |  | 561d |  |  |  |  |
| 63 | 5.3 | **Pagrindinės įrangos parinkimas ir suderinimas** |  | 55d | 2021-12-22 | 2022-03-14 |  | 2020-05-19 | 2020-06-19 | 24d | 0d |  |  | 3520h |  |
| 64 | 5.3.1 | **Elektrotechnika [E]** |  | 55d | 2021-12-22 | 2022-03-14 |  | 2020-05-19 | 2020-06-19 | 24d | 509d |  |  | 440h |  |
| 65 | 5.3.1.1 | Parinkta elektrotechnikos dalies įranga ir pateikti 1 peržiūrai užpildyti techninių specifikacijų atitikimai LITGRID AB |  | 30d | 2021-12-22 | 2022-02-03 | 58 | 2020-05-19 | 2020-06-01 | 10d | 509d | 0d | Rangovas | 240h |  |
| 66 | 5.3.1.2 | Pateiktos pastabos užpildytoms techninėms specifikacijoms |  | 10d | 2022-02-03 | 2022-02-18 | 65 | 2020-06-02 | 2020-06-15 | 10d | 509d | 0d | Litgrid AB | 80h |  |
| 67 | 5.3.1.3 | Patikslinti techninių specifikacijų atitikimai ir pateikti 2 peržiūrai Litgrid AB |  | 5d | 2022-02-18 | 2022-02-25 | 66 | 2020-06-16 | 2020-06-17 | 2d | 509d | 0d | Rangovas | 40h |  |
| 68 | 5.3.1.4 | Patvirtinti techninių specifikacijų atitikimai - įranga suderinta |  | 10d | 2022-02-25 | 2022-03-14 | 67 | 2020-06-18 | 2020-06-19 | 2d | 509d |  | Litgrid AB | 80h |  |
| 69 | 5.3.2 | **Elektrotechnika (EL)** |  | 55d | 2021-12-22 | 2022-03-14 |  | 2020-05-19 | 2020-06-12 | 19d | 509d |  |  | 440h |  |
| 70 | 5.3.2.1 | Parinktos EL dalies medžiagos ir pateikti 1 peržiūrai užpildyti techninių specifikacijų atitikimai LITGRID AB |  | 30d | 2021-12-22 | 2022-02-03 | 58 | 2020-05-19 | 2020-05-25 | 5d | 509d | 0d | Rangovas | 240h |  |
| 71 | 5.3.2.2 | Pateiktos pastabos užpildytoms techninėms specifikacijoms |  | 10d | 2022-02-03 | 2022-02-18 | 70 | 2020-05-26 | 2020-06-08 | 10d | 509d | 0d | Litgrid AB | 80h |  |
| 72 | 5.3.2.3 | Patikslinti techninių specifikacijų atitikimai ir pateikti 2 peržiūrai Litgrid AB |  | 5d | 2022-02-18 | 2022-02-25 | 71 | 2020-06-09 | 2020-06-10 | 2d | 509d | 0d | Rangovas | 40h |  |
| 73 | 5.3.2.4 | Patvirtinti techninių specifikacijų atitikimai - įranga suderinta |  | 10d | 2022-02-25 | 2022-03-14 | 72 | 2020-06-11 | 2020-06-12 | 2d | 509d |  | Litgrid AB | 80h |  |
| 74 | 5.3.3 | **Procesų valdymas ir automatizacija (RAA)** |  | 55d | 2021-12-22 | 2022-03-14 |  | 2020-05-19 | 2020-06-19 | 24d | 0d |  |  | 440h |  |
| 75 | 5.3.3.1 | Parinkta RAA dalies įranga ir pateikti 1 peržiūrai užpildyti techninių specifikacijų atitikimai LITGRID AB |  | 30d | 2021-12-22 | 2022-02-03 | 58 | 2020-05-19 | 2020-06-01 | 10d | 0d |  | Rangovas | 240h |  |
| 76 | 5.3.3.2 | Pateiktos pastabos užpildytoms techninėms specifikacijoms |  | 10d | 2022-02-03 | 2022-02-18 | 75 | 2020-06-02 | 2020-06-15 | 10d | 0d |  | Litgrid AB | 80h |  |
| 77 | 5.3.3.3 | Patikslinti techninių specifikacijų atitikimai ir pateikti 2 peržiūrai Litgrid AB |  | 5d | 2022-02-18 | 2022-02-25 | 76 | 2020-06-16 | 2020-06-17 | 2d | 0d |  | Rangovas | 40h |  |
| 78 | 5.3.3.4 | Patvirtinti techninių specifikacijų atitikimai - įranga suderinta |  | 10d | 2022-02-25 | 2022-03-14 | 77 | 2020-06-18 | 2020-06-19 | 2d | 0d |  | Litgrid AB | 80h |  |

Notes:
- 60: jei perkame atskirai (tik projektavim¹) - trinti �i¹ dalį/ jei perkame iki rakto - paliekame
- 62: vykdo u˛sakovas

| ID | WBS | Task | Type | Duration | Start | Finish | Predecessors | Baseline start | Baseline finish | Baseline duration | Total slack | Free slack | Resources | Work |
| --- | --- | --- | --- | --- | --- | --- | --- | --- | --- | --- | --- | --- | --- | --- |
| 79 | 5.3.4 | **Procesų valdymas ir automatizacija (TSPĮ)** |  | 55d | 2021-12-22 | 2022-03-14 |  | 2020-05-19 | 2020-06-12 | 19d | 509d |  |  | 440h |
| 80 | 5.3.4.1 | Parinkta TSPĮ dalies įranga ir pateikti 1 peržiūrai užpildyti techninių specifikacijų atitikimai LITGRID AB |  | 30d | 2021-12-22 | 2022-02-03 | 58 | 2020-05-19 | 2020-05-25 | 5d | 509d | 0d | Rangovas | 240h |
| 81 | 5.3.4.2 | Pateiktos pastabos užpildytoms techninėms specifikacijoms |  | 10d | 2022-02-03 | 2022-02-18 | 80 | 2020-05-26 | 2020-06-08 | 10d | 509d | 0d | Litgrid AB | 80h |
| 82 | 5.3.4.3 | Patikslinti techninių specifikacijų atitikimai ir pateikti 2 peržiūrai Litgrid AB |  | 5d | 2022-02-18 | 2022-02-25 | 81 | 2020-06-09 | 2020-06-10 | 2d | 509d | 0d | Rangovas | 40h |
| 83 | 5.3.4.4 | Patvirtinti techninių specifikacijų atitikimai - įranga suderinta |  | 10d | 2022-02-25 | 2022-03-14 | 82 | 2020-06-11 | 2020-06-12 | 2d | 509d |  | Litgrid AB | 80h |
| 84 | 5.3.5 | **Procesų valdymas ir automatizacija (EEA)** |  | 55d | 2021-12-22 | 2022-03-14 |  | 2020-05-19 | 2020-06-12 | 19d | 509d |  |  | 440h |
| 85 | 5.3.5.1 | Parinkta EEA dalies įranga ir pateikti 1 peržiūrai užpildyti techninių specifikacijų atitikimai LITGRID AB |  | 30d | 2021-12-22 | 2022-02-03 | 58 | 2020-05-19 | 2020-05-25 | 5d | 509d | 0d | Rangovas | 240h |
| 86 | 5.3.5.2 | Pateiktos pastabos užpildytoms techninėms specifikacijoms |  | 10d | 2022-02-03 | 2022-02-18 | 85 | 2020-05-26 | 2020-06-08 | 10d | 509d | 0d | Litgrid AB | 80h |
| 87 | 5.3.5.3 | Patikslinti techninių specifikacijų atitikimai ir pateikti 2 peržiūrai Litgrid AB |  | 5d | 2022-02-18 | 2022-02-25 | 86 | 2020-06-09 | 2020-06-10 | 2d | 509d | 0d | Rangovas | 40h |
| 88 | 5.3.5.4 | Patvirtinti techninių specifikacijų atitikimai - įranga suderinta |  | 10d | 2022-02-25 | 2022-03-14 | 87 | 2020-06-11 | 2020-06-12 | 2d | 509d |  | Litgrid AB | 80h |
| 89 | 5.3.6 | **Telekomunikacijos (TK)** |  | 55d | 2021-12-22 | 2022-03-14 |  | 2020-05-19 | 2020-06-12 | 19d | 509d |  |  | 440h |
| 90 | 5.3.6.1 | Parinkta telekomunikacijos dalies įranga ir pateikti 1 peržiūrai užpildyti techninių specifikacijų atitikimai LITGRID AB |  | 30d | 2021-12-22 | 2022-02-03 | 58 | 2020-05-19 | 2020-05-25 | 5d | 509d | 0d | Rangovas | 240h |
| 91 | 5.3.6.2 | Pateiktos pastabos užpildytoms techninėms specifikacijoms |  | 10d | 2022-02-03 | 2022-02-18 | 90 | 2020-05-26 | 2020-06-08 | 10d | 509d | 0d | Litgrid AB | 80h |
| 92 | 5.3.6.3 | Patikslinti techninių specifikacijų atitikimai ir pateikti pakartotinei peržiūrai Litgrid AB |  | 5d | 2022-02-18 | 2022-02-25 | 91 | 2020-06-09 | 2020-06-10 | 2d | 509d | 0d | Rangovas | 40h |
| 93 | 5.3.6.4 | Patvirtinti techninių specifikacijų atitikimai - įranga suderinta |  | 10d | 2022-02-25 | 2022-03-14 | 92 | 2020-06-11 | 2020-06-12 | 2d | 509d |  | Litgrid AB | 80h |
| 94 | 5.3.7 | **Apsauginė-gaisrinė signalizacija (AGS)** |  | 55d | 2021-12-22 | 2022-03-14 |  | 2020-05-19 | 2020-06-12 | 19d | 509d |  |  | 440h |
| 95 | 5.3.7.1 | Parinkta AGS dalies įranga ir pateikti peržiūrai užpildyti techninių specifikacijų atitikimai LITGRID AB |  | 30d | 2021-12-22 | 2022-02-03 | 58 | 2020-05-19 | 2020-05-25 | 5d | 509d | 0d | Rangovas | 240h |
| 96 | 5.3.7.2 | Pateiktos pastabos užpildytoms techninėms specifikacijoms |  | 10d | 2022-02-03 | 2022-02-18 | 95 | 2020-05-26 | 2020-06-08 | 10d | 509d | 0d | Litgrid AB | 80h |
| 97 | 5.3.7.3 | Patikslinti techninių specifikacijų atitikimai ir pateikti pakartotinei peržiūrai Litgrid AB |  | 5d | 2022-02-18 | 2022-02-25 | 96 | 2020-06-09 | 2020-06-10 | 2d | 509d | 0d | Rangovas | 40h |
| 98 | 5.3.7.4 | Patvirtinti techninių specifikacijų atitikimai - įranga suderinta |  | 10d | 2022-02-25 | 2022-03-14 | 97 | 2020-06-11 | 2020-06-12 | 2d | 509d |  | Litgrid AB | 80h |
| 99 | 5.3.8 | **Statybinės konstrukcijos (SK)** |  | 55d | 2021-12-22 | 2022-03-14 |  | 2020-05-19 | 2020-06-12 | 19d | 509d |  |  | 440h |
| 100 | 5.3.8.1 | Parinktos SK dalies medžiagos ir pateikti peržiūrai užpildyti techninių specifikacijų atitikimai LITGRID AB |  | 30d | 2021-12-22 | 2022-02-03 | 58 | 2020-05-19 | 2020-05-25 | 5d | 509d | 0d | Rangovas | 240h |
| 101 | 5.3.8.2 | Pateiktos pastabos užpildytoms techninėms specifikacijoms |  | 10d | 2022-02-03 | 2022-02-18 | 100 | 2020-05-26 | 2020-06-08 | 10d | 509d | 0d | Litgrid AB | 80h |
| 102 | 5.3.8.3 | Patikslinti techninių specifikacijų atitikimai ir pateikti pakartotinei peržiūrai Litgrid AB |  | 5d | 2022-02-18 | 2022-02-25 | 101 | 2020-06-09 | 2020-06-10 | 2d | 509d | 0d | Rangovas | 40h |
| 103 | 5.3.8.4 | Patvirtinti techninių specifikacijų atitikimai - įranga suderinta |  | 10d | 2022-02-25 | 2022-03-14 | 102 | 2020-06-11 | 2020-06-12 | 2d | 509d | 0d | Litgrid AB | 80h |
| 104 | 5.4 | Pateikti įrodantys dokumentai, kad Pagrindiniai įrenginiai yra užsakyti | milestone | 0d | 2022-03-14 | 2022-03-14 | 103 |  |  |  | 509d |  |  |  |

Notes:
- 104: Pagrindiniai įrenginiai - įrenginiai, kurie Sutartyje ir/ar kituose Pirkimo dokumentuose nurodyti kaip pagrindiniai.

| ID | WBS | Task | Type | Duration | Start | Finish | Predecessors | Baseline start | Baseline finish | Baseline duration | Total slack | Free slack | Resources | Work |
| --- | --- | --- | --- | --- | --- | --- | --- | --- | --- | --- | --- | --- | --- | --- |
| 105 | 5.5 | **RAA nuostatų pateikimas I statybos etapui** |  | 68d | 2022-03-14 | 2022-06-17 |  | 2020-06-22 | 2020-09-21 | 64d | 0d |  |  | 544h |
| 106 | 5.5.1 | OL RAA nuostatų I rekonstrukcijos etapui skaičiavimas |  | 21d | 2022-03-14 | 2022-04-12 | 78 |  |  |  | 0d |  | Litgrid AB | 168h |
| 107 | 5.5.2 | OL RAA nuostatų I rekonstrukcijos etapo užduočių rengimas |  | 13d | 2022-04-12 | 2022-05-02 | 106 |  |  |  | 0d |  | Litgrid AB | 104h |
| 108 | 5.5.3 | Šynų; prijunginių jungtuvų RAA nuostatų I rekonstrukcijos etapui skaičiavimas ir užduočių rengimas |  | 13d | 2022-05-02 | 2022-05-19 | 107 |  |  |  | 0d |  | Litgrid AB | 104h |
| 109 | 5.5.4 | Galios transformatorių įvadų TS- 100 RAA nuostatų skaičiavimas 15 dienų |  | 15d | 2022-05-19 | 2022-06-09 | 108 |  |  |  | 0d |  | Litgrid AB | 120h |
| 110 | 5.5.5 | I rekonstrukcijos etapo užduočių rengimas |  | 5d | 2022-06-09 | 2022-06-16 | 109 |  |  |  | 0d |  | Litgrid AB | 40h |
| 111 | 5.5.6 | Užduočių pateikimas |  | 1d | 2022-06-16 | 2022-06-17 | 110 |  |  |  | 0d |  | Litgrid AB | 8h |
| 112 | 5.6 | **I darbų etapo signalų sąrašai** |  | 50d | 2022-06-17 | 2022-08-31 |  |  |  |  | 0d |  |  | 640h |
| 113 | 5.6.1 | Suprojektuoti ir pateikti 1 peržiūrai ir derinimui XX TP; bei kitų su XX TP rekonstrukcija susijusių objektų (pagal poreikį); signalų sąrašai Litgrid AB ir ESO |  | 10d | 2022-06-17 | 2022-07-04 | 111 | 2020-10-21 | 2020-11-10 | 15d | 0d |  | Rangovas | 80h |
| 114 | 5.6.2 | Pateiktos pastabos po 1 peržiūros |  | 15d | 2022-07-04 | 2022-07-26 | 113 | 2020-11-11 | 2020-12-01 | 15d | 0d |  | Litgrid AB; ESO | 240h |
| 115 | 5.6.3 | Pakoreguoti pagal pastabas ir pateikti 2 peržiūrai ir derinimui signalų sąrašai Litgrid AB ir ESO |  | 5d | 2022-07-26 | 2022-08-02 | 114 | 2020-12-02 | 2020-12-08 | 5d | 0d |  | Rangovas | 40h |
| 116 | 5.6.4 | Pateiktos pastabos po 2 peržiūros |  | 10d | 2022-08-02 | 2022-08-17 | 115 | 2020-12-09 | 2020-12-22 | 10d | 0d |  | Litgrid AB; ESO | 160h |
| 117 | 5.6.5 | Pakoreguoti pagal pastabas ir pateikti III peržiūrai ir derinimui signalų sąrašai Litgrid AB ir ESO |  | 5d | 2022-08-17 | 2022-08-24 | 116 | 2020-12-23 | 2020-12-31 | 5d | 0d |  | Rangovas | 40h |
| 118 | 5.6.6 | I darbų etapo signalų sąrašai suderinti |  | 5d | 2022-08-24 | 2022-08-31 | 117 | 2021-01-04 | 2021-01-08 | 5d | 0d |  | Litgrid AB; ESO | 80h |
| 119 | 5.7 | Gamybos ir montavimo brėžinių derinimas |  | 85d | 2020-09-28 | 2021-01-27 |  | 2020-08-19 | 2021-01-28 | 114d | 775d | 0d |  |  |
| 120 | 5.8 | Rangovas pateikia prašymą dėl IP dresų suteikimo |  | 1d | 2021-01-27 | 2021-01-28 | 119 |  |  |  | 782d | 0d |  |  |
| 121 | 5.9 | IP adresų suteikimas TSPĮ;MDV;GPS;RAA įrenginiams |  | 10d | 2021-01-28 | 2021-02-11 | 120 |  |  |  | 782d |  | Litgrid AB | 80h |
| 122 | 5.10 | **Darbų-atjungimų grafikas** |  | 54d | 2022-04-22 | 2022-07-11 |  |  |  |  | 409d |  |  | 752h |
| 123 | 5.10.1 | Pateiktas darbų-atjungimų grafikas 1 periūrai | milestone | 0d | 2022-04-22 | 2022-04-22 | 137SS-90d |  |  |  | 409d | 0d | Rangovas |  |
| 124 | 5.10.2 | Pateiktos pastabos po 1 peržiūros |  | 15d | 2022-04-22 | 2022-05-13 | 123 |  |  |  | 409d | 0d | Litgrid AB; ESO | 240h |
| 125 | 5.10.3 | Pateiktas darbų-atjungimų grafikas 2 peržiūrai |  | 7d | 2022-05-13 | 2022-05-24 | 124 |  |  |  | 409d | 0d | Rangovas | 56h |
| 126 | 5.10.4 | Pateiktos pastabos po 2 peržiūros |  | 15d | 2022-05-24 | 2022-06-14 | 125 |  |  |  | 409d | 0d | Litgrid AB; ESO | 240h |
| 127 | 5.10.5 | Pateiktas darbų-atjungimų grafikas 3 peržiūrai |  | 7d | 2022-06-14 | 2022-06-23 | 126 |  |  |  | 409d | 0d | Rangovas | 56h |
| 128 | 5.10.6 | Suderintas darbų-atjungimų grafikas |  | 10d | 2022-06-23 | 2022-07-11 | 127, 137SS-60d |  |  |  | 409d | 0d | Litgrid AB; ESO | 160h |
| 129 | 5.11 | Suderintas technologinis projektas |  | 1d | 2022-07-14 | 2022-07-15 | 133, 128, 119 |  |  |  | 423d |  |  |  |
| 130 | 5.12 | Pranešimas IS Infostatyba apie statybos pradžią Užsakovo vardu |  | 1d | 2022-07-14 | 2022-07-15 | 133, 128, 119 |  |  |  | 423d |  |  |  |
| 131 | 5.13 | Gautas tinkamas statybos darbų ir rangovo civilinės atsakomybės draudimo polisas |  | 15d | 2022-07-14 | 2022-08-04 | 133, 128, 119 |  |  |  | 409d |  |  |  |
| 132 | 5.14 | ESDŽ (Elektroninis statybos darbų žurnalas) suderintas |  | 15d | 2022-07-14 | 2022-08-04 | 133, 128, 119 |  |  |  | 409d |  |  |  |
| 133 | 5.15 | Statybos aikštelės perdavimas rangovui |  | 3d | 2022-07-11 | 2022-07-14 | 128, 119 |  |  |  | 409d | 0d | Litgrid AB | 24h |
| 134 | 5.16 | Pasirašytas tarpusavio saugos darbe atsakomybės ribų aktas |  | 15d | 2022-07-14 | 2022-08-04 | 133 |  |  |  | 409d |  |  |  |
| 135 | 5.17 | Pasirašytas leidimas kasimo darbams |  | 15d | 2022-07-14 | 2022-08-04 | 133 |  |  |  | 409d |  |  |  |

Notes:
- 119: Dėl terminų ir apimties gamybos montavimo brėinių nėra susitarta. Siūloma detalizuoti rangovui.
- 120: Reikia RAA nuostatų ir signalų sąrašo suderinto
- 129: jei taikoma
- 135: jei taikoma

| ID | WBS | Task | Duration | Start | Finish | Predecessors | Total slack | Free slack | Resources | Work | Cost |
| --- | --- | --- | --- | --- | --- | --- | --- | --- | --- | --- | --- |
| 136 | 5.18 | **I etapo statybos darbai** | 178d | 2022-08-31 | 2023-05-15 |  | 0d |  | Rangovas | 2816h | 427.2 |
| 137 | 5.18.1 | Rangovas detalizuoja darbus | 90d | 2022-08-31 | 2023-01-06 | 118 | 0d |  |  |  |  |
| 138 | 5.18.2 | Principinės objekto schemos pateikimas (OL permaitinimai ir kt. Pagal suderintą atjungimų grafiką) | 3d | 2022-08-31 | 2022-09-05 | 137SS | 385d | 0d | Rangovas | 24h |  |
| 139 | 5.18.3 | TSM modelio keitimas (dėl I etapo išmontuojamos dalies) | 3d | 2022-09-05 | 2022-09-08 | 138 | 385d |  | _ITTAD ITTC VSG DVS administratorius | 24h | 427.2 |
| 140 | 5.18.4 | RAA derinimo darbai | 15d | 2023-01-06 | 2023-01-27 | 137, 118 | 0d |  | Rangovas | 120h |  |
| 141 | 5.18.5 | TSPĮ įrangos derinimo darbai | 15d | 2023-01-27 | 2023-02-20 | 140 | 0d |  | Rangovas | 120h |  |
| 142 | 5.18.6 | Teleinformacijos testavimai tarp RAA terminalų (valdiklių) ir TSPĮ | 1d | 2023-02-20 | 2023-02-21 | 141 | 264d | 0d | Rangovas; Litgrid AB | 16h |  |
| 143 | 5.18.7 | Ryšių; įrangos derinimo darbai | 15d | 2023-01-27 | 2023-02-20 | 141SS | 0d |  | Rangovas | 120h |  |
| 144 | 5.18.8 | Užsakymo pateikimas duomenų telekomunikacijų įrangos prijungimui į Litgrid AB TDPT | 1d | 2023-02-20 | 2023-02-21 | 143 | 0d |  | Rangovas | 8h |  |
| 145 | 5.18.9 | Litgrid AB TDPT įrangos parengimas/konfigūravimas naujos telekomunikacijų įrangos (IP; SDH; RRL; Šviesolaidis) prijungimui | 4d | 2023-02-21 | 2023-02-27 | 144 | 0d |  | Litgrid AB | 32h |  |
| 146 | 5.18.10 | RAA OĮB rengimas/tvirtinimas | 10d | 2023-02-20 | 2023-03-06 | 141, 143 | 251d | 0d | Rangovas; Litgrid AB | 160h |  |
| 147 | 5.18.11 | Tipinių perjungimo lapelių ruošimas/tvirtinimas | 10d | 2023-03-06 | 2023-03-20 | 146 | 251d |  | Rangovas | 80h |  |
| 148 | 5.18.12 | **DVS (SCADA/EMS) parengiamieji darbai kompleksiniams bandymams (DVS realaus laiko displėjų parengimas; DVS vystymo sistemos konfigūravimas)** | 11d | 2022-08-31 | 2022-09-15 |  | 124d |  |  | 88h |  |
| 149 | 5.18.12.1 | DVS vystymo sistemos konfigūravimas pagal paskutinį suderintą signalų sąrašą | 3d | 2022-08-31 | 2022-09-05 | 118 | 124d | 0d | Litgrid AB | 24h |  |
| 150 | 5.18.12.2 | Principinės objekto schemos pateikimas; linijų; transformatorių parametrų pateikimas | 3d | 2022-09-05 | 2022-09-08 | 149 | 124d | 0d | Rangovas | 24h |  |
| 151 | 5.18.12.3 | DVS realaus laiko displėjų parengimas | 5d | 2022-09-08 | 2022-09-15 | 149, 150 | 124d |  | Litgrid AB | 40h |  |
| 152 | 5.18.13 | TSPĮ konfigūracijos pateikimas | 1d | 2023-02-21 | 2023-02-22 | 142 | 264d | 0d | Rangovas | 8h |  |
| 153 | 5.18.14 | TSPĮ konfigūracijos derinimas su užsakovu | 5d | 2023-02-22 | 2023-03-01 | 152 | 264d |  | Litgrid AB | 40h |  |
| 154 | 5.18.15 | Įrenginių testavimas bandymai objekte ir/ar tarp skirtingų objektų (pasiruošimas kompleksiniams bandymas) | 10d | 2023-02-27 | 2023-03-13 | 145 | 0d |  | Rangovas | 80h |  |
| 155 | 5.18.16 | Įrenginių kompleksiniai bandymai su PSO SCADA | 7d | 2023-03-13 | 2023-03-22 | 151, 154 | 0d |  | Rangovas; Litgrid AB | 112h |  |
| 156 | 5.18.17 | **DVS (SCADA/EMS) baigiamieji etapo darbai** | 11d | 2023-03-22 | 2023-04-06 |  | 0d |  |  | 120h |  |
| 157 | 5.18.17.1 | Konfigūracijos perkėlimas iš vystymo DVS į darbinę DVS | 1d | 2023-03-22 | 2023-03-23 | 155 | 0d |  | Litgrid AB | 8h |  |
| 158 | 5.18.17.2 | Skaičiuojamųjų matavimų sukonfigūravimas DVS | 3d | 2023-03-23 | 2023-03-28 | 157 | 0d |  | Litgrid AB | 24h |  |
| 159 | 5.18.17.3 | DVS realaus laiko displėjų parengimo užbaigimas | 7d | 2023-03-28 | 2023-04-06 | 158 | 238d |  | Litgrid AB | 56h |  |
| 160 | 5.18.17.4 | DVS teisių koregavimas (jeigu įtraukiamas naujas objektas) | 1d | 2023-03-28 | 2023-03-29 | 158 | 0d |  | Litgrid AB | 8h |  |
| 161 | 5.18.17.5 | TSM modelio keitimas (dėl I etapo) | 2d | 2023-03-29 | 2023-03-31 | 160, 150 | 0d |  | Litgrid AB | 16h |  |
| 162 | 5.18.17.6 | TDPT naujos įrangos įvedimas į monitoringo ir valdymo sistemas | 1d | 2023-03-31 | 2023-04-03 | 161 | 0d |  | Litgrid AB | 8h |  |

| ID | WBS | Task | Type | Duration | Start | Finish | Predecessors | Total slack | Free slack | Resources | Work | Cost |
| --- | --- | --- | --- | --- | --- | --- | --- | --- | --- | --- | --- | --- |
| 163 | 5.18.18 | **Techninio įvertinimo komisija (I etapo)** |  | 28d | 2023-04-03 | 2023-05-15 |  | 0d |  |  | 240h |  |
| 164 | 5.18.18.1 | Techninės dokumentacijos pateikimas Užsakovui |  | 5d | 2023-04-03 | 2023-04-11 | 162 | 0d |  | Rangovas | 40h |  |
| 165 | 5.18.18.2 | Tech priežiūra derina/pateikia pastabas dokumentacijai |  | 7d | 2023-04-11 | 2023-04-20 | 164 | 0d |  | Litgrid AB | 56h |  |
| 166 | 5.18.18.3 | Operatyvinio personalo mokymai |  | 1d | 2023-04-20 | 2023-04-21 | 165 | 0d |  | Rangovas | 8h |  |
| 167 | 5.18.18.4 | Rangovas pateikia raštą dėl TĮK organizavimo (su tech. priežiūros vadovo parašu) |  | 1d | 2023-04-21 | 2023-04-24 | 166 | 0d |  | Rangovas | 8h |  |
| 168 | 5.18.18.5 | TĮK organizavimas |  | 7d | 2023-04-24 | 2023-05-04 | 167 | 0d |  | Litgrid AB | 56h |  |
| 169 | 5.18.18.6 | Techninio įvertinimo komisija | milestone | 0d | 2023-05-04 | 2023-05-04 | 168 | 0d |  | Rangovas; Litgrid AB |  |  |
| 170 | 5.18.18.7 | TĮK pastabų šalinimas |  | 5d | 2023-05-04 | 2023-05-11 | 169 | 0d |  | Rangovas | 40h |  |
| 171 | 5.18.18.8 | TP įjungimas; bandomoji ekspoatacija |  | 2d | 2023-05-11 | 2023-05-15 | 170 | 0d |  | Rangovas; Litgrid AB | 32h |  |
| 172 | 5.18.18.9 | TP įjungta | milestone | 0d | 2023-05-15 | 2023-05-15 | 171 | 0d |  | Rangovas; Litgrid AB |  |  |
| 173 | 5.19 | **II etapo statybos darbai** |  | 162d | 2023-05-15 | 2024-01-04 |  | 0d |  | Rangovas | 4264h | 4,984 |
| 174 | 5.19.1 | Rangovas detalizuoja darbus |  | 70d | 2023-05-15 | 2023-08-23 | 172 | 0d |  |  |  |  |
| 175 | 5.19.2 | **RAA nuostatų pateikimas II statybos etapui** |  | 35d | 2023-05-15 | 2023-07-03 |  | 29d |  |  | 280h |  |
| 176 | 5.19.2.1 | OL RAA nuostatų II rekonstrukcijos etapui skaičiavimas |  | 21d | 2023-05-15 | 2023-06-13 | 174SS | 29d | 0d | Litgrid AB | 168h |  |
| 177 | 5.19.2.2 | OL RAA nuostatų II rekonstrukcijos etapo užduočių rengimas |  | 13d | 2023-06-13 | 2023-06-30 | 176 | 29d | 0d | Litgrid AB | 104h |  |
| 178 | 5.19.2.3 | Užduočių pateikimas |  | 1d | 2023-06-30 | 2023-07-03 | 177 | 29d | 0d | Litgrid AB | 8h |  |
| 179 | 5.19.3 | **Gretimų TP RAA nuostatų pateikimas** |  | 31d | 2023-07-03 | 2023-08-17 |  | 76d |  |  | 248h |  |
| 180 | 5.19.3.1 | OL RAA nuostatų gretimose TP skaičiavimas |  | 20d | 2023-07-03 | 2023-08-01 | 178 | 76d | 0d | Litgrid AB | 160h |  |
| 181 | 5.19.3.2 | OL RAA nuostatų gretimose TP užduočių rengimas |  | 10d | 2023-08-01 | 2023-08-16 | 180 | 76d | 0d | Litgrid AB | 80h |  |
| 182 | 5.19.3.3 | Užduočių pateikimas |  | 1d | 2023-08-16 | 2023-08-17 | 181 | 76d |  | Litgrid AB | 8h |  |
| 183 | 5.19.4 | **II darbų etapo signalų sąrašai** |  | 40d | 2023-07-03 | 2023-08-30 |  | 29d |  |  | 320h |  |
| 184 | 5.19.4.1 | Suprojektuoti ir pateikti 1 peržiūrai ir derinimui XX TP; bei kitų su XX TP rekonstrukcija susijusių objektų (pagal poreikį); signalų sąrašai Litgrid AB ir ESO |  | 10d | 2023-07-03 | 2023-07-18 | 178 | 29d | 0d | Rangovas | 80h |  |
| 185 | 5.19.4.2 | Pateiktos pastabos po 1 peržiūros |  | 10d | 2023-07-18 | 2023-08-01 | 184 | 29d | 0d | Litgrid AB | 80h |  |
| 186 | 5.19.4.3 | Pakoreguoti pagal pastabas ir pateikti 2 peržiūrai ir derinimui signalų sąrašai Litgrid AB ir ESO |  | 5d | 2023-08-01 | 2023-08-08 | 185 | 29d | 0d | Rangovas | 40h |  |
| 187 | 5.19.4.4 | Pateiktos pastabos po 2 peržiūros |  | 5d | 2023-08-08 | 2023-08-16 | 186 | 29d | 0d | Litgrid AB | 40h |  |
| 188 | 5.19.4.5 | Pakoreguoti pagal pastabas ir pateikti III peržiūrai ir derinimui signalų sąrašai Litgrid AB ir ESO |  | 5d | 2023-08-16 | 2023-08-23 | 187 | 29d | 0d | Rangovas | 40h |  |
| 189 | 5.19.4.6 | II darbų etapo signalų sąrašai suderinti |  | 5d | 2023-08-23 | 2023-08-30 | 188 | 29d | 0d | Litgrid AB | 40h |  |
| 190 | 5.19.5 | Principinės objekto schemos pateikimas (OL permaitinimai ir kt. Pagal suderintą atjungimų grafiką) |  | 3d | 2023-05-15 | 2023-05-18 | 174SS | 207d | 0d | Rangovas | 24h |  |
| 191 | 5.19.6 | TSM modelio keitimas (dėl II etapo išmontuojamos dalies) |  | 3d | 2023-05-18 | 2023-05-23 | 190 | 207d |  | _ITTAD ITTC VSG DVS administratorius | 24h | 427.2 |
| 192 | 5.19.7 | RAA derinimo darbai |  | 15d | 2023-08-23 | 2023-09-13 | 174 | 0d |  | Rangovas | 120h |  |
| 193 | 5.19.8 | TSPĮ įrangos derinimo darbai |  | 15d | 2023-09-13 | 2023-10-04 | 192 | 0d |  | Rangovas | 120h |  |
| 194 | 5.19.9 | Pastotės RAA terminalų; teleinformacijos surinkimo ir perdavimo įrenginių (TSPĮ); ryšių įrangos; informacijos saugumo reikalavimų išpildymo tikrinimas su LITGRID AB. |  | 1d | 2023-10-03 | 2023-10-04 | 193FF | 113d |  | Rangovas | 8h |  |
| 195 | 5.19.10 | Teleinformacijos testavimai tarp RAA terminalų (valdiklių) ir TSPĮ |  | 1d | 2023-10-04 | 2023-10-05 | 193 | 106d | 0d | Rangovas; Litgrid AB | 16h |  |
| 196 | 5.19.11 | Ryšių; įrangos derinimo darbai |  | 15d | 2023-09-13 | 2023-10-04 | 193SS | 0d |  | Rangovas | 120h |  |
| 197 | 5.19.12 | Užsakymo pateikimas duomenų telekomunikacijų įrangos prijungimui į Litgrid AB TDPT |  | 1d | 2023-10-04 | 2023-10-05 | 196 | 0d |  | Litgrid AB | 8h |  |
| 198 | 5.19.13 | Litgrid AB TDPT įrangos parengimas/konfigūravimas naujos telekomunikacijų įrangos (IP; SDH; RRL; Šviesolaidis) prijungimui (Litgrid AB) |  | 4d | 2023-10-05 | 2023-10-11 | 197 | 0d |  | _ITTAD ITTC DPG duomenų tinklo administratorius (KR); _ITTAD ITTC TIG vyresnysis inžinierius; Litgrid AB; _ITTAD ITTC DPG duomenų tinklo administratorius (IP) | 128h | 1,708.8 |
| 199 | 5.19.14 | RAA OĮB rengimas/tvirtinimas |  | 10d | 2023-10-04 | 2023-10-18 | 193, 196 | 93d | 0d | Rangovas; Litgrid AB | 160h |  |
| 200 | 5.19.15 | Tipinių perjungimo lapelių ruošimas/tvirtinimas |  | 10d | 2023-10-18 | 2023-11-02 | 199 | 93d |  | Rangovas | 80h |  |

| ID | WBS | Task | Type | Duration | Start | Finish | Predecessors | Total slack | Free slack | Resources | Work | Cost |
| --- | --- | --- | --- | --- | --- | --- | --- | --- | --- | --- | --- | --- |
| 201 | 5.19.16 | **DVS (SCADA/EMS) parengiamieji darbai kompleksiniams bandymams (DVS realaus laiko displėjų parengimas; DVS pagrindinio/rezervinio centro konfigūravimas)** |  | 11d | 2023-08-30 | 2023-09-14 |  | 29d |  |  | 88h |  |
| 202 | 5.19.16.1 | DVS pagrindinio/rezervinio centro konfigūravimas atsižvelgiant į etapo pasikeitmus 3-5 d.d. |  | 3d | 2023-08-30 | 2023-09-04 | 189 | 29d | 0d | Litgrid AB | 24h |  |
| 203 | 5.19.16.2 | Principinės objekto schemos pateikimas; linijų; transformatorių parametrų pateikimas |  | 3d | 2023-09-04 | 2023-09-07 | 202 | 29d | 0d | Rangovas | 24h |  |
| 204 | 5.19.16.3 | DVS realaus laiko displėjų parengimas 3-5 d.d. (SVD darbai) |  | 5d | 2023-09-07 | 2023-09-14 | 202, 203 | 29d |  | Litgrid AB | 40h |  |
| 205 | 5.19.17 | TSPĮ konfigūracijos pateikimas |  | 1d | 2023-10-05 | 2023-10-06 | 195 | 106d | 0d | Rangovas | 8h |  |
| 206 | 5.19.18 | TSPĮ konfigūracijos derinimas su užsakovu (Litgrid AB) |  | 5d | 2023-10-09 | 2023-10-13 | 205 | 106d |  | Litgrid AB | 40h |  |
| 207 | 5.19.19 | II etapo įrenginių testavimas bandymai objekte ir/ar tarp skirtingų objektų (pasiruošimas kompleksiniams bandymas) |  | 10d | 2023-10-11 | 2023-10-25 | 198 | 0d |  | Rangovas | 80h |  |
| 208 | 5.19.20 | II etapo įrenginių kompleksiniai bandymai su PSO SCADA |  | 7d | 2023-10-25 | 2023-11-06 | 204, 207 | 0d |  | Rangovas; Litgrid AB | 112h |  |
| 209 | 5.19.21 | **DVS (SCADA/EMS) baigiamojo etapo darbai)** |  | 56d | 2023-09-07 | 2023-11-27 |  | 76d |  |  | 488h | 2,848 |
| 210 | 5.19.21.1 | Skaičiuojamųjų matavimų koregavimas DVS |  | 3d | 2023-11-07 | 2023-11-09 | 208 | 76d | 0d | Litgrid AB | 24h |  |
| 211 | 5.19.21.2 | DVS realaus laiko displėjų parengimo užbaigimas |  | 7d | 2023-11-09 | 2023-11-20 | 210 | 76d | 0d | Litgrid AB | 56h |  |
| 212 | 5.19.21.3 | Pateikiama rekonstrukcijos II etapo schema ir parametrai |  | 5d | 2023-11-21 | 2023-11-27 | 211 | 76d |  | Rangovas | 40h |  |
| 213 | 5.19.21.4 | TSM modelio keitimas (dėl II etapo) |  | 2d | 2023-09-07 | 2023-09-11 | 203 | 96d | 0d | Litgrid AB | 16h |  |
| 214 | 5.19.21.5 | Visos būtinos dokumentacijos įrenginių įjungimui patvirtinimas/vizavimas; Pateiktas galutinis TPL sąrašas suvedimui į DVS |  | 2d | 2023-09-11 | 2023-09-13 | 213 | 96d | 0d | Rangovas | 16h |  |
| 215 | 5.19.21.6 | Automatinių tipinių perjungimo lapelių suvedimas į PSO DVS |  | 20d | 2023-09-13 | 2023-10-11 | 214 | 96d | 0d | _ITTAD ITTC VSG DVS administratorius | 160h | 2,848 |
| 216 | 5.19.21.7 | Automatinių tipinių perjungimo lapelių testavimas realiomis sąlygomis |  | 10d | 2023-10-11 | 2023-10-25 | 215 | 96d | 0d | Rangovas; Litgrid AB | 160h |  |
| 217 | 5.19.21.8 | TDPT naujos įrangos įvedimas į monitoringo ir valdymo sistemas |  | 2d | 2023-10-25 | 2023-10-27 | 216 | 96d |  | Litgrid AB | 16h |  |
| 218 | 5.19.22 | **Techninio įvertinimo komisija (II etapo)** |  | 20d | 2023-11-07 | 2023-12-04 |  | 0d |  |  | 336h |  |
| 219 | 5.19.22.1 | Techninės dokumentacijos pateikimas Užsakovui pagal techninės užduoties reikalavimus |  | 1d | 2023-11-07 | 2023-11-07 | 208 | 0d |  | Rangovas | 8h |  |
| 220 | 5.19.22.2 | Techninės dokumentacijos pateikimas ir derinimas su Užsakovu pagal techninės užduoties reikalavimus |  | 5d | 2023-11-07 | 2023-11-14 | 219 | 0d |  | Litgrid AB | 192h |  |
| 221 | 5.19.22.3 | Operatyvinio personalo mokymai |  | 1d | 2023-11-14 | 2023-11-15 | 220 | 0d |  | Rangovas | 8h |  |
| 222 | 5.19.22.4 | Įjungimo programos rengimas ir derinimas |  | 5d | 2023-11-15 | 2023-11-22 | 221 | 0d |  | Rangovas | 40h |  |
| 223 | 5.19.22.5 | Techninio įvertinimo komisija (II etapo) |  | 1d | 2023-11-22 | 2023-11-23 | 222 | 0d |  | Rangovas; Litgrid AB | 16h |  |
| 224 | 5.19.22.6 | Techninio įvertinimo komisijos (II etapo) pastabų šalinimas |  | 5d | 2023-11-23 | 2023-11-30 | 223 | 0d |  | Rangovas | 40h |  |
| 225 | 5.19.22.7 | TP įjungimas; bandomoji ekspoatacija |  | 2d | 2023-11-30 | 2023-12-04 | 224 | 0d |  | Rangovas; Litgrid AB | 32h |  |
| 226 | 5.19.22.8 | TP įjungta | milestone | 0d | 2023-12-04 | 2023-12-04 | 225 | 0d |  | Rangovas; Litgrid AB |  |  |
| 227 | 5.19.23 | RAA nuostatų keitimas gretimose TP |  | 20d | 2023-12-05 | 2024-01-04 | 226, 182 | 0d |  | Rangovas | 160h |  |
| 228 | 5.19.24 | RANGOS DARBAI OBJEKTE BAIGTI | milestone | 0d | 2024-01-04 | 2024-01-04 | 227 | 0d |  |  |  |  |

Notes:
- 201: (3-5 d.d. priklauso nuo apimties, kiekvieno projekto metu derinama atskirai)
- 209: (14-30 d.d. priklauso nuo apimties, kiekvieno projekto metu derinama atskirai)
- 215: (10-20 d.d.; 50 operacijų į dieną kartu su testavimu imitatoriumi)

| ID | WBS | Task | Type | Duration | Start | Finish | Predecessors | Baseline start | Baseline finish | Baseline duration | Total slack | Resources | Work |
| --- | --- | --- | --- | --- | --- | --- | --- | --- | --- | --- | --- | --- | --- |
| 229 | 6 | **III ETAPAS. STATYBOS UŽBAIGIMO AKTAS** |  | 51d | 2024-01-05 | 2024-03-19 |  | 2022-01-19 | 2022-02-18 | 22d | 0d |  | 816h |
| 230 | 6.1 | Išpildomosios topografinės nuotraukos parengimas |  | 20d | 2024-01-05 | 2024-02-01 | 228 |  |  |  | 0d | Rangovas | 160h |
| 231 | 6.2 | **Statinių kadastrinės bylos parengimas; suderinimas ir registrų centro išankstinė patikra** |  | 18d | 2024-02-02 | 2024-02-28 |  |  |  |  | 0d | Rangovas | 288h |
| 232 | 6.2.1 | Rangovas rengia statinių kadastrinė bylą |  | 10d | 2024-02-02 | 2024-02-15 | 230 |  |  |  | 0d | Rangovas | 80h |
| 233 | 6.2.2 | Statinių kadastrinės bylos derinimas |  | 5d | 2024-02-19 | 2024-02-23 | 232 |  |  |  | 0d | Litgrid AB | 40h |
| 234 | 6.2.3 | Statinių kadastrinės bylos išankstinis suderinimas su registrų centru |  | 3d | 2024-02-26 | 2024-02-28 | 233 |  |  |  | 0d | Rangovas | 24h |
| 235 | 6.3 | **Žemės sklypo kadastrinės bylos parengimas; suderinimas ir registrų centro išankstinė patikra** |  | 18d | 2024-02-02 | 2024-02-28 |  |  |  |  | 0d |  | 144h |
| 236 | 6.3.1 | Rangovas rengia žemės sklypo kadastrinė bylą |  | 10d | 2024-02-02 | 2024-02-15 | 230 |  |  |  | 0d | Rangovas | 80h |
| 237 | 6.3.2 | Žemės sklypo kadastrinės bylos derinimas |  | 5d | 2024-02-19 | 2024-02-23 | 236 |  |  |  | 0d | Litgrid AB | 40h |
| 238 | 6.3.3 | Žemės sklypo kadastrinės bylos išankstinis suderinimas su registrų centru |  | 3d | 2024-02-26 | 2024-02-28 | 237 |  |  |  | 0d | Rangovas | 24h |
| 239 | 6.4 | **Statybos užbaigimo procedūrų organizavimas** |  | 13d | 2024-02-28 | 2024-03-19 |  | 2022-01-19 | 2022-02-15 | 20d | 0d | Rangovas | 224h |
| 240 | 6.4.1 | SUA prašymo dokumentų įkėlimas į IS Infostatyba |  | 3d | 2024-02-28 | 2024-03-04 | 234, 238 |  |  |  | 0d | Rangovas | 24h |
| 241 | 6.4.2 | Preliminaraus SUA suderinimas su Litgrid AB (atspausdintas iš IS Infostatyba) |  | 3d | 2024-03-04 | 2024-03-07 | 240 |  |  |  | 0d | Litgrid AB | 24h |
| 242 | 6.4.3 | SUA prašymo pateikimas Infostatyboje |  | 2d | 2024-03-07 | 2024-03-12 | 241 |  |  |  | 0d | Rangovas | 16h |
| 243 | 6.4.4 | Dokumentų peržiūra |  | 3d | 2024-03-12 | 2024-03-18 | 242 |  |  |  | 0d | Infostatyba | 24h |
| 244 | 6.4.5 | Galutinė statybos užbaigimo komisija |  | 2d | 2024-03-18 | 2024-03-19 | 243 | 2022-02-17 | 2022-02-18 | 2d | 0d | Infostatyba; Rangovas | 32h |
| 245 | 6.4.6 | S8 - SUA gautas/Rangos sutarties pabaiga | milestone | 0d | 2024-03-19 | 2024-03-19 | 244 |  |  |  | 0d | Rangovas |  |

Notes:
- 229: Jeigu perkame iki rakto - paliekame / jeigu perkame atskirai - pa�alinti
